Schedule from MS Project, 2025-10-01 to 2026-01-23.
Microsoft

## Calendars

- Стандартный: Mon-Sun 09:00-13:00, 14:00-18:00.

## Schedule

| ID | WBS | Task | Duration | Start | Finish | Predecessors | Total slack |
| --- | --- | --- | --- | --- | --- | --- | --- |
| 1 | 1 | **Выполнение работ по ремонту и замене железнодорожного пути и стрелочных переводов** | 115d | 2025-10-01 | 2026-01-23 |  | 0d |
| 2 | 1.1 | Закупка и поставка материалов | 14d | 2025-10-01 | 2025-10-14 |  | 0d |
| 3 | 1.2 | Путевые работы | 100d | 2025-10-15 | 2026-01-22 | 2 | 1d |
| 4 | 1.3 | Демонтаж СП б/н 1/6, правая | 7d | 2025-10-15 | 2025-10-21 | 2 | 0d |
| 5 | 1.4 | Демонтаж СП3 1/6, правая | 7d | 2025-10-22 | 2025-10-28 | 4 | 0d |
| 6 | 1.5 | Демонтаж СП15 1/9, правая | 7d | 2025-10-29 | 2025-11-04 | 5 | 0d |
| 7 | 1.6 | Замена СП6 1/7, левая | 10d | 2025-11-05 | 2025-11-14 | 6 | 0d |
| 8 | 1.7 | Замена СП7 1/7, левая | 10d | 2025-11-15 | 2025-11-24 | 7 | 0d |
| 9 | 1.8 | Замена СП8 1/7, левая | 10d | 2025-11-25 | 2025-12-04 | 8 | 0d |
| 10 | 1.9 | Замена СП9 1/7, левая | 10d | 2025-12-05 | 2025-12-14 | 9 | 0d |
| 11 | 1.10 | Замена СП10 1/7, левая | 10d | 2025-12-15 | 2025-12-24 | 10 | 0d |
| 12 | 1.11 | Замена СП11 1/7, левая | 10d | 2025-12-25 | 2026-01-03 | 11 | 0d |
| 13 | 1.12 | Замена СП13 1/7, левая | 10d | 2026-01-04 | 2026-01-13 | 12 | 0d |
| 14 | 1.13 | Замена СП14 1/7, правая | 10d | 2026-01-14 | 2026-01-23 | 13 | 0d |
